# Puente

Schedule from MS Project, 2008-10-01 to 2009-03-26, costs in €.
uc3m

## Calendars

- Estándar: Mon-Fri 09:00-13:00, 15:00-19:00; Sat-Sun off. Exceptions (off unless hours are given): 2008-12-08, 2008-12-25, 2009-01-01, 2009-01-06, 2009-03-19.

## Resources

| Resource | Rate | Cost per use |
| --- | --- | --- |
| Topógrafo | 12.5 |  |
| Porta mira | 7.5 |  |
| Peones | 6.88 |  |
| Albañiles | 9.38 |  |
| Bulldozer con conductor | 18.75 | 60 |
| Grúa | 18.75 | 100 |
| Hormigonera | 1.88 |  |

## Schedule

| ID | WBS | Task | Duration | Start | Finish | Predecessors | Total slack | Free slack | Resources | Work | Cost |
| --- | --- | --- | --- | --- | --- | --- | --- | --- | --- | --- | --- |
| 1 | 1 | **Topografía** | 109.5d | 2008-10-01 | 2009-03-09 |  | 0d |  |  | 112h | 970 |
| 2 | 1.1 | Implantación topográfica | 3d | 2008-10-01 | 2008-10-03 |  | 0d |  | Topógrafo; Porta mira; Peones [200%] | 96h | 810 |
| 3 | 1.2 | Control topográfico antes de colocación de vigas | 0.5d | 2009-02-24 | 2009-02-24 | 34 | 1.5d |  | Topógrafo; Porta mira | 8h | 80 |
| 4 | 1.3 | Control topográfico después de colocación de vigas | 0.5d | 2009-03-09 | 2009-03-09 | 37 | 0d |  | Topógrafo; Porta mira | 8h | 80 |
| 5 | 2 | **Instalación de la obra** | 20d | 2008-10-06 | 2008-10-31 |  | 0d |  |  | 772h | 5,395 |
| 6 | 2.1 | Colocación planta de hormigonado | 15d | 2008-10-13 | 2008-10-31 | 2 | 0d |  | Peones [400%]; Grúa [10%]; Hormigonera | 612h | 3,760 |
| 7 | 2.2 | Instalación de la obra | 5d | 2008-10-06 | 2008-10-10 | 2 | 5d | 0d | Peones [300%]; Bulldozer con conductor | 160h | 1,635 |
| 8 | 3 | **Prefabricación pilotes. Ferralla y encofrado** | 15d | 2008-10-13 | 2008-10-31 |  | 10d |  |  | 360h | 3,075 |
| 9 | 3.1 | Ferralla y encofrado lote 1 | 5d | 2008-10-13 | 2008-10-17 | 7 | 10d | 0d | Peones; Albañiles [200%] | 120h | 1,025 |
| 10 | 3.2 | Ferralla y encofrado lote 2 | 5d | 2008-10-20 | 2008-10-24 | 9 | 16d | 0d | Peones; Albañiles [200%] | 120h | 1,025 |
| 11 | 3.3 | Ferralla y encofrado lote 3 | 5d | 2008-10-27 | 2008-10-31 | 10 | 38d | 0d | Peones; Albañiles [200%] | 120h | 1,025 |
| 12 | 4 | **Prefebricación pilotes. Hormigonado** | 10d | 2008-11-03 | 2008-11-14 |  | 0d |  |  | 144h | 930 |
| 13 | 4.1 | Hormigonado lote 1 | 1d | 2008-11-03 | 2008-11-03 | 6, 9 | 0d |  | Peones [400%]; Albañiles; Hormigonera | 48h | 310 |
| 14 | 4.2 | Hormigonado lote 2 | 1d | 2008-11-13 | 2008-11-13 | 10 | 16d | 9d | Peones [400%]; Albañiles; Hormigonera | 48h | 310 |
| 15 | 4.3 | Hormigonado lote 3 | 1d | 2008-11-14 | 2008-11-14 | 11 | 34d | 22d | Peones [400%]; Albañiles; Hormigonera | 48h | 310 |
| 16 | 5 | **Hincado de pilotes** | 32d | 2008-11-24 | 2009-01-12 |  | 0d |  |  | 432h | 4,980 |
| 17 | 5.1 | Hincado de pilotes de pilar A | 6d | 2008-11-24 | 2008-12-01 | 21, 13FS+15ed | 0d |  | Peones [200%]; Grúa | 144h | 1,660 |
| 18 | 5.2 | Hincado de pilotes de pilar B | 6d | 2008-12-12 | 2008-12-19 | 22, 14FS+15ed | 7d | 0d | Peones [200%]; Grúa | 144h | 1,660 |
| 19 | 5.3 | Hincado de pilotes de pilar C | 6d | 2009-01-02 | 2009-01-12 | 23, 15FS+15ed | 14d |  | Peones [200%]; Grúa | 144h | 1,660 |
| 20 | 6 | **Diques provisionales** | 78d | 2008-11-04 | 2009-02-25 |  | 0d |  |  | 552h | 6,380 |
| 21 | 6.1 | Instalación de diques provisionales pilar A | 7d | 2008-11-04 | 2008-11-12 | 7 | 4d |  | Peones [200%]; Grúa | 168h | 1,920 |
| 22 | 6.2 | Instalación de diques provisionales pilar B | 7d | 2008-12-02 | 2008-12-11 | 17 | 7d | 0d | Peones [200%]; Grúa | 168h | 1,920 |
| 23 | 6.3 | Instalación de diques provisionales pilar C | 7d | 2008-12-22 | 2008-12-31 | 18, 26 | 14d | 0d | Peones [200%]; Grúa | 168h | 1,920 |
| 24 | 6.4 | Recuperación de planchas | 2d | 2009-02-24 | 2009-02-25 | 34 | 0d |  | Peones [200%]; Grúa | 48h | 620 |

| ID | WBS | Task | Type | Duration | Start | Finish | Predecessors | Total slack | Free slack | Resources | Work | Cost |
| --- | --- | --- | --- | --- | --- | --- | --- | --- | --- | --- | --- | --- |
| 25 | 7 | **Pasarela** |  | 78d | 2008-11-17 | 2009-03-10 |  | 10.5d |  |  | 308h | 3,287.5 |
| 26 | 7.1 | Instalación pasarelas |  | 5d | 2008-11-17 | 2008-11-21 | 7 | 33d | 19d | Peones [200%]; Albañiles [200%]; Grúa [90%] | 196h | 2,065 |
| 27 | 7.2 | Desmontaje pasarelas |  | 7d | 2009-03-02 | 2009-03-10 | 24 | 10.5d |  | Peones; Albañiles [50%]; Grúa [50%] | 112h | 1,222.5 |
| 28 | 8 | **Hormigonado de pilares** |  | 56d | 2008-12-02 | 2009-02-23 |  | 0d |  |  | 2240h | 15,400 |
| 29 | 8.1 | Confección traviesas pilar A |  | 5d | 2008-12-02 | 2008-12-09 | 17 | 0d |  | Peones [200%]; Albañiles [200%]; Hormigonera | 200h | 1,375 |
| 30 | 8.2 | Hormigonado pilar A |  | 15d | 2008-12-10 | 2008-12-31 | 29 | 0d |  | Peones [200%]; Albañiles [200%]; Hormigonera | 600h | 4,125 |
| 31 | 8.3 | Confección traviesas pilar B |  | 5d | 2009-01-02 | 2009-01-09 | 18, 30 | 0d |  | Peones [200%]; Albañiles [200%]; Hormigonera | 200h | 1,375 |
| 32 | 8.4 | Hormigonado pilar B |  | 15d | 2009-01-12 | 2009-01-30 | 31 | 0d |  | Peones [200%]; Albañiles [200%]; Hormigonera | 600h | 4,125 |
| 33 | 8.5 | Confección traviesas pilar C |  | 5d | 2009-02-02 | 2009-02-06 | 19, 32 | 0d |  | Peones [200%]; Albañiles [200%]; Hormigonera | 200h | 1,375 |
| 34 | 8.6 | Hormigonado pilar C |  | 11d | 2009-02-09 | 2009-02-23 | 33 | 0d |  | Peones [200%]; Albañiles [200%]; Hormigonera | 440h | 3,025 |
| 35 | 9 | **Tablero** |  | 14.5d | 2009-02-26 | 2009-03-18 |  | 0d |  |  | 476h | 4,325 |
| 36 | 9.1 | Colocación vigas prefabricadas |  | 2d | 2009-02-26 | 2009-02-27 | 3, 24 | 0d |  | Peones [200%]; Albañiles [200%]; Grúa | 80h | 920 |
| 37 | 9.2 | Encofrado tablero |  | 5d | 2009-03-02 | 2009-03-06 | 36 | 0d |  | Peones [200%]; Albañiles [200%]; Grúa [5%] | 162h | 1,342.5 |
| 38 | 9.3 | Ferralla tablero |  | 5d | 2009-03-09 | 2009-03-16 | 4, 37 | 0d |  | Peones [200%]; Albañiles [200%]; Grúa [5%] | 162h | 1,342.5 |
| 39 | 9.4 | Hormigonado tablero |  | 2d | 2009-03-16 | 2009-03-18 | 38 | 0d |  | Peones [200%]; Albañiles [200%]; Grúa [50%] | 72h | 720 |
| 40 | 10 | **Pretil** |  | 121.5d | 2008-10-01 | 2009-03-26 |  | 0d |  |  | 160h | 1,775 |
| 41 | 10.1 | Pedido pretil | milestone | 0d | 2008-10-01 | 2008-10-01 |  | 96.5d |  |  |  |  |
| 42 | 10.2 | Colocación pretil |  | 5d | 2009-03-18 | 2009-03-26 | 39, 41FS+20d | 0d |  | Peones [200%]; Albañiles; Grúa | 160h | 1,775 |
